# Belle II Project January 2011 mit Pilot

Schedule from MS Project, 2008-07-01 to 2014-10-01, A marks actual dates.
tste

## Calendars

- Standard: Mon-Fri 08:00-12:00, 13:00-17:00; Sat-Sun off.

## Resources

| Resource |
| --- |
| Lead Institute MPI |
| Collaborating Institute KRA |
| Collaborating Institute PRA |
| Lead Institute HEI |
| Lead Institute BON |
| Collaborating Institute MPI |
| Collaborating Institute UBA |
| Collaborating Institute USC |
| Collaborating Institute URL |
| Collaborating Institute HEI |
| Collaborating Institute BON |
| Collaborating Institute IFV |
| Collaborationg Institute CNM |
| Collaborating Institute IFB |
| Lead Institute KEK |
| Collaborating Institute VIE |
| Lead Institute KAR |
| Lead Institute KRA |
| Collaborating Institute KEK |
| Collaborating Institute MPI |
| Collaborating Institute GOE |
| Collaborating Institute HAW |
| Collaborating Institute CNM |

## Schedule

| ID | WBS | Task | Type | Duration | Start | Finish | Predecessors | Complete | Remaining | Total slack | Free slack | Constraint | Deadline | Resources | Work | Actual work |
| --- | --- | --- | --- | --- | --- | --- | --- | --- | --- | --- | --- | --- | --- | --- | --- | --- |
| 1 | 1 | SuperKEKB IP design fixed | milestone | 0d | 2010-10-01 | 2010-10-01 |  |  |  | -121d | 0d | start no earlier than 2010-10-01 |  |  |  |  |
| 2 | 2 | Belle II TDR | milestone | 0d | 2010-03-31 A | 2010-03-31 A |  | 100% |  |  |  | start no earlier than 2010-03-31 |  |  |  |  |
| 3 | 3 | PXD FDR I (ASIC, Sensor) | milestone | 0d | 2011-05-13 | 2011-05-13 | 117, 90 |  |  | -215d | 0d | start no earlier than 2010-12-21 |  |  |  |  |
| 4 | 4 | PXD FDR II (System) | milestone | 0d | 2012-03-29 | 2012-03-29 | 265, 303, 320 |  |  | -83d | 0d | start no earlier than 2011-12-23 |  |  |  |  |
| 5 | 5 | **1.0 DEPFET Detector** |  | 1486d? | 2008-07-09 A | 2014-03-19 |  | 40% | 896.26d? | -208d | 0d |  | 2013-05-31 |  | 256280h | 43688.3h |
| 6 | 5.1 | **1.1 Parameter Definitions** |  | 607d? | 2009-01-01 A | 2011-04-29 |  | 85% | 91.05d? | 0d |  |  |  | Lead Institute MPI; Collaborating Institute KRA; Collaborating Institute PRA | 14568h | 12382.8h |
| 7 | 5.1.1 | Parameter Studies |  | 607d? | 2009-01-01 A | 2011-04-29 |  | 85% | 91.05d? | 0d |  | finish no earlier than 2011-04-29 |  |  |  |  |
| 8 | 5.2 | **1.2 Pixel Sensor** |  | 1456d? | 2008-07-09 A | 2014-02-05 |  | 55% | 653.33d? | -418d | 0d |  | 2012-06-29 | Lead Institute MPI | 11648h | 1601.15h |
| 9 | 5.2.1 | plasma etch test and evaluation |  | 160d? | 2009-10-01 A | 2010-05-12 A |  | 100% |  |  |  | finish no earlier than 2010-05-12 |  |  |  |  |
| 10 | 5.2.2 | **UBM and 3rd metal layer (Cu)** |  | 540d? | 2009-05-01 A | 2011-05-26 |  | 68% | 173.52d? | 286d |  |  |  |  |  |  |
| 11 | 5.2.2.1 | Test wafers for CNM |  | 36d? | 2009-05-01 A | 2009-06-19 A |  | 100% |  |  |  | start no earlier than 2009-05-01 |  |  |  |  |
| 12 | 5.2.2.2 | UBM and bonding at CNM |  | 464d? | 2009-06-22 A | 2011-03-31 | 11 | 80% | 92.8d? | 286d | 0d | finish no earlier than 2011-03-31 |  |  |  |  |
| 13 | 5.2.2.3 | evaluation |  | 2mo | 2011-04-01 | 2011-05-26 | 12 |  |  | 286d |  |  |  |  |  |  |
| 14 | 5.2.2.4 | Copper comissioing at HLL |  | 3mo | 2011-01-03 | 2011-03-25 |  |  |  | -212d | 0d | start no earlier than 2011-01-03 |  |  |  |  |
| 15 | 5.2.3 | **PXD6.1** |  | 733d? | 2008-07-09 A | 2011-04-29 |  | 92% | 57.18d? | -44d | 0d |  |  |  |  |  |
| 16 | 5.2.3.1 | PXD6.1 Design |  | 228d? | 2008-07-09 A | 2009-05-22 A |  | 100% |  |  |  | finish no earlier than 2009-05-22 |  |  |  |  |
| 17 | 5.2.3.2 | Layout Deadline (Chip size) | milestone | 0d | 2008-12-23 A | 2008-12-23 A |  | 100% |  |  |  | start no earlier than 2008-12-23 |  |  |  |  |
| 18 | 5.2.3.3 | Wafer Delivery | milestone | 0d | 2008-10-13 A | 2008-10-13 A |  | 100% |  |  |  | finish no earlier than 2008-10-13 |  |  |  |  |
| 19 | 5.2.3.4 | **SOI preparation** |  | 85d | 2009-01-27 A | 2009-05-25 A | 18 | 100% |  |  |  |  |  |  |  |  |
| 20 | 5.2.3.4.1 | Oxydation |  | 1w | 2009-01-27 A | 2009-02-02 A |  | 100% |  |  |  | start no earlier than 2009-01-27 |  |  |  |  |
| 21 | 5.2.3.4.2 | Backside Lithography |  | 9d | 2009-02-03 A | 2009-02-13 A | 17, 20 | 100% |  |  |  | finish no earlier than 2009-02-13 |  |  |  |  |
| 22 | 5.2.3.4.3 | Backside Implantation |  | 5d | 2009-02-23 A | 2009-02-27 A | 21 | 100% |  |  |  | start no earlier than 2009-02-23 |  |  |  |  |
| 23 | 5.2.3.4.4 | SOI wafer Bonding |  | 8w | 2009-03-31 A | 2009-05-25 A | 22 | 100% |  |  |  | finish no earlier than 2009-05-25 |  |  |  |  |
| 24 | 5.2.3.5 | **PXD6.1 production** |  | 394d | 2009-05-26 A | 2010-11-26 A | 23, 16, 19 | 100% |  |  |  |  | 2010-06-30 |  |  |  |
| 25 | 5.2.3.5.1 | frontside processing |  | 354d | 2009-05-26 A | 2010-10-01 A | 19 | 100% |  |  |  | finish no earlier than 2010-10-01 |  |  |  |  |

| ID | WBS | Task | Duration | Start | Finish | Predecessors | Complete | Remaining | Total slack | Free slack | Constraint | Deadline |
| --- | --- | --- | --- | --- | --- | --- | --- | --- | --- | --- | --- | --- |
| 26 | 5.2.3.5.2 | **thinning** | 40d | 2010-10-04 A | 2010-11-26 A |  | 100% |  |  |  |  |  |
| 27 | 5.2.3.5.2.1 | Etching handle wafer | 8w | 2010-10-04 A | 2010-11-26 A | 25 | 100% |  |  |  | start no earlier than 2010-05-04 |  |
| 28 | 5.2.3.6 | **PXD6.1b production** | 500d | 2009-05-26 A | 2011-04-25 |  | 87% | 63d | -40d | 0d |  | 2010-06-30 |
| 29 | 5.2.3.6.1 | frontside processing | 460d | 2009-05-26 A | 2011-02-28 |  | 95% | 23d | 0d |  | finish no earlier than 2011-02-28 |  |
| 30 | 5.2.3.6.2 | **thinning of 1b** | 40d | 2011-03-01 | 2011-04-25 |  |  |  | -213d | 0d |  |  |
| 31 | 5.2.3.6.2.1 | Etching handle wafer | 8w | 2011-03-01 | 2011-04-25 | 29 |  |  | -213d | 0d | start no earlier than 2010-05-04 |  |
| 32 | 5.2.3.7 | **PXD6.1c production (for DHP)** | 504d | 2009-05-26 A | 2011-04-29 |  | 87% | 67.33d | -50d | 0d |  | 2010-06-30 |
| 33 | 5.2.3.7.1 | frontside processing | 454d | 2009-05-26 A | 2011-02-18 A |  | 100% |  |  |  | finish no earlier than 2011-02-18 |  |
| 34 | 5.2.3.7.2 | metal II | 2w | 2011-02-21 | 2011-03-04 | 33, 116 |  |  | -217d | 0d |  |  |
| 35 | 5.2.3.7.3 | **thinning of 1c** | 40d | 2011-03-07 | 2011-04-29 |  |  |  | -217d | 0d |  |  |
| 36 | 5.2.3.7.3.1 | Etching handle wafer | 8w | 2011-03-07 | 2011-04-29 | 34 |  |  | -217d | 0d | start no earlier than 2010-05-04 |  |
| 37 | 5.2.3.7.3.2 | copper UBM | 1mo | 2011-03-28 | 2011-04-22 | 14 |  |  | -212d | 0d |  |  |
| 38 | 5.2.4 | PXD6.1 tests on wafer level | 154d? | 2010-10-04 A | 2011-05-05 A | 25 | 100% |  |  |  | start no earlier than 2010-04-30 |  |
| 39 | 5.2.5 | PXD6.1 evaluation | 119d | 2010-12-27 | 2011-06-09 | 321, 24, 27 |  |  | 276d |  | finish no earlier than 2010-12-23 |  |
| 40 | 5.2.6 | **PXD6.2 Studies** | 409d? | 2010-01-05 A | 2011-07-29 |  | 43% | 234.56d? | -142d | 0d |  |  |
| 41 | 5.2.6.1 | **Thin oxide optimization** | 267d? | 2010-01-05 A | 2011-01-12 |  | 88% | 32d? | 0d |  |  |  |
| 42 | 5.2.6.1.1 | test wafer production (Test XFEL) | 139d? | 2010-01-05 A | 2010-07-16 A |  | 100% |  |  |  | finish no earlier than 2010-07-16 |  |
| 43 | 5.2.6.1.2 | mesurements & evaluation | 128d? | 2010-07-19 A | 2011-01-12 |  | 75% | 32d? | 0d |  | finish no earlier than 2011-01-12 |  |
| 44 | 5.2.6.2 | **Nitride Tests** | 100d? | 2011-02-01 | 2011-06-20 |  |  |  | -397d | 0d |  |  |
| 45 | 5.2.6.2.1 | Design | 1mo | 2011-02-01 | 2011-02-28 |  |  |  | -397d | 0d | start no earlier than 2011-02-01 |  |
| 46 | 5.2.6.2.2 | Prodessing | 2mo? | 2011-03-01 | 2011-04-25 | 45 |  |  | -397d | 0d |  |  |
| 47 | 5.2.6.2.3 | Evaluation | 2mo | 2011-04-26 | 2011-06-20 | 46 |  |  | -397d | 0d |  |  |
| 48 | 5.2.6.3 | **SOI test production** | 135d? | 2011-01-24 | 2011-07-29 |  |  |  | -418d | 0d |  |  |
| 49 | 5.2.6.3.1 | Thinning, Polishing studies at DISCO, Rookwood | 49d? | 2011-01-24 | 2011-03-31 |  |  |  | -412d | 0d | finish no earlier than 2011-03-31 |  |
| 50 | 5.2.6.3.2 | oxydation | 1w | 2011-01-24 | 2011-01-28 |  |  |  | -418d | 0d | start no earlier than 2011-01-24 |  |
| 51 | 5.2.6.3.3 | backside lithography | 1w | 2011-01-31 | 2011-02-04 | 50 |  |  | -418d | 0d | start no earlier than 2011-01-28 |  |
| 52 | 5.2.6.3.4 | backside implantation | 5d | 2011-02-07 | 2011-02-11 | 51 |  |  | -418d | 0d | start no earlier than 2010-01-18 |  |
| 53 | 5.2.6.3.5 | SOI bonding at VTT | 8w | 2011-02-14 | 2011-04-08 | 52 |  |  | -418d | 0d | start no earlier than 2010-01-25 |  |
| 54 | 5.2.6.3.6 | SOI test evaluation | 4w | 2011-04-11 | 2011-05-06 | 53, 49 |  |  | -418d | 0d |  |  |
| 55 | 5.2.6.3.7 | 2nd SOI evaluation | 3mo | 2011-05-09 | 2011-07-29 | 54 |  |  | -418d | 0d | start no earlier than 2011-05-06 |  |

| ID | WBS | Task | Type | Duration | Start | Finish | Predecessors | Total slack | Free slack | Constraint | Deadline |
| --- | --- | --- | --- | --- | --- | --- | --- | --- | --- | --- | --- |
| 56 | 5.2.7 | **PXD6.2** |  | 512d | 2011-05-02 | 2013-04-16 | 53 | -418d | 0d |  |  |
| 57 | 5.2.7.1 | **PXD6.2 Design** |  | 116d | 2011-05-02 | 2011-10-10 | 7, 41 | -397d | 0d |  |  |
| 58 | 5.2.7.1.1 | Design Studies/Simulations |  | 56d | 2011-05-02 | 2011-07-18 |  | -337d | 0d |  |  |
| 59 | 5.2.7.1.2 | Final Design |  | 3mo | 2011-06-21 | 2011-09-12 | 47 | -397d | 0d |  |  |
| 60 | 5.2.7.1.3 | Design verification |  | 1mo | 2011-09-13 | 2011-10-10 | 59 | -397d | 0d |  |  |
| 61 | 5.2.7.2 | fix final sensor dimensions | milestone | 0d | 2011-05-02 | 2011-05-02 | 260, 1 | -348d | 0d | start no earlier than 2011-05-02 |  |
| 62 | 5.2.7.3 | wafer delivery | milestone | 0d | 2011-07-12 | 2011-07-12 |  | -404d | 0d | start no earlier than 2011-07-12 |  |
| 63 | 5.2.7.4 | **SOI preparation** |  | 72d | 2011-08-01 | 2011-11-08 | 62 | -418d | 0d |  |  |
| 64 | 5.2.7.4.1 | oxydation |  | 1w | 2011-08-01 | 2011-08-05 | 55 | -418d | 0d | start no earlier than 2011-05-04 |  |
| 65 | 5.2.7.4.2 | backside lithography |  | 1w | 2011-08-08 | 2011-08-12 | 64, 61 | -418d | 0d | finish no earlier than 2010-12-10 |  |
| 66 | 5.2.7.4.3 | backside implantation |  | 2d | 2011-08-15 | 2011-08-16 | 65 | -418d | 0d | start no earlier than 2010-12-13 |  |
| 67 | 5.2.7.4.4 | SOI production |  | 12w | 2011-08-17 | 2011-11-08 | 66 | -418d | 0d | start no earlier than 2011-01-03 |  |
| 68 | 5.2.7.5 | **PXD6.2 production (Pilot)** |  | 375d | 2011-11-09 | 2013-04-16 | 67, 57, 63 | -418d | 0d |  | 2012-06-30 |
| 69 | 5.2.7.5.1 | frontside processing |  | 12mo | 2011-11-09 | 2012-10-09 | 57, 3 | -418d | 0d | start no earlier than 2011-10-27 |  |
| 70 | 5.2.7.5.2 | metal layers |  | 3mo | 2012-10-10 | 2013-01-01 | 69, 14 | -418d | 0d |  |  |
| 71 | 5.2.7.5.3 | **thinning** |  | 75d | 2013-01-02 | 2013-04-16 |  | -418d | 0d |  |  |
| 72 | 5.2.7.5.3.1 | UBM & Etching handle wafer |  | 15w | 2013-01-02 | 2013-04-16 | 70 | -418d | 0d | start no earlier than 2010-01-14 |  |
| 73 | 5.2.8 | PXD6.2 production first wafers finished | milestone | 0d | 2013-04-16 | 2013-04-16 | 72 | -271d | 0d |  |  |
| 74 | 5.2.9 | **PXD6.2 production (Main)** |  | 435d | 2012-03-01 | 2013-10-30 | 63 | -368d | 0d |  | 2012-06-30 |
| 75 | 5.2.9.1 | frontside processing |  | 15mo | 2012-03-01 | 2013-04-24 |  | -368d | 0d | start no earlier than 2012-03-01 |  |
| 76 | 5.2.9.2 | metal layers |  | 3mo | 2013-04-25 | 2013-07-17 | 75 | -368d | 0d |  |  |
| 77 | 5.2.9.3 | **thinning** |  | 75d | 2013-07-18 | 2013-10-30 |  | -368d | 0d |  |  |
| 78 | 5.2.9.3.1 | UBM & Etching handle wafer |  | 15w | 2013-07-18 | 2013-10-30 | 76 | -368d | 0d | start no earlier than 2010-01-14 |  |
| 79 | 5.2.10 | **Sensor Tests** |  | 211d | 2013-04-17 | 2014-02-05 | 71 | -418d | 0d |  |  |
| 80 | 5.2.10.1 | Sensor tests |  | 211d | 2013-04-17 | 2014-02-05 |  | -418d | 0d | start no earlier than 2013-04-17 |  |
| 81 | 5.2.10.2 | First sensor tested |  | 2.4mo | 2013-04-17 | 2013-06-21 |  | -319d | 0d | start no earlier than 2013-04-16 |  |
| 82 | 5.2.10.3 | First sensors of main batch testet |  | 1mo | 2013-10-31 | 2013-11-27 | 78 | -368d | 0d |  |  |

| ID | WBS | Task | Duration | Start | Finish | Predecessors | Complete | Remaining | Total slack | Free slack | Constraint | Resources | Work | Actual work |
| --- | --- | --- | --- | --- | --- | --- | --- | --- | --- | --- | --- | --- | --- | --- |
| 83 | 5.3 | **1.3 ASIC** | 1103d? | 2008-11-11 A | 2013-01-31 |  | 50% | 548.53d? | 86d |  |  |  | 39632h | 5901.87h |
| 84 | 5.3.1 | **1.3.1 DCD** | 1066d? | 2009-01-01 A | 2013-01-31 |  | 47% | 561.05d? | 86d |  |  | Lead Institute HEI | 8528h | 1545.55h |
| 85 | 5.3.1.1 | DCD2 prototype | 1d? | 2009-01-01 A | 2009-01-01 A |  | 100% |  |  |  |  |  |  |  |
| 86 | 5.3.1.2 | DCD2 tests | 173d? | 2009-01-01 A | 2009-08-31 A |  | 100% |  |  |  | finish no earlier than 2009-04-08 |  |  |  |
| 87 | 5.3.1.3 | DCDB redesign | 5.95mo | 2009-09-01 A | 2010-02-12 A | 86 | 100% |  |  |  | finish no earlier than 2010-02-12 |  |  |  |
| 88 | 5.3.1.4 | DCDB1 production | 12w | 2010-02-15 A | 2010-05-07 A | 87, 319 | 100% |  |  |  | start no earlier than 2010-02-15 |  |  |  |
| 89 | 5.3.1.5 | DCDB1 evaluation | 3mo | 2010-05-10 A | 2010-07-30 | 88 | 50% | 1.5mo | 640d | 265d |  |  |  |  |
| 90 | 5.3.1.6 | DCDB design correction | 2mo | 2010-08-30 A | 2010-10-22 A | 89 | 100% |  |  |  | finish no earlier than 2010-10-22 |  |  |  |
| 91 | 5.3.1.7 | DCDB Test Chip production | 3mo | 2010-10-25 A | 2011-01-14 | 90 | 90% | 0.3mo | -83d | 0d |  |  |  |  |
| 92 | 5.3.1.8 | DCDB test ecaluation | 54d? | 2011-01-17 | 2011-03-31 | 91 |  |  | -83d | 0d | finish no earlier than 2011-03-31 |  |  |  |
| 93 | 5.3.1.9 | DCDB2 production | 8mo | 2011-04-01 | 2011-11-10 | 92 |  |  | -83d | 0d | start no earlier than 2011-03-31 |  |  |  |
| 94 | 5.3.1.10 | DCDB2 tests | 3mo | 2011-11-11 | 2012-02-02 | 93 |  |  | 56d | 40d | start no earlier than 2011-09-15 |  |  |  |
| 95 | 5.3.1.11 | DCDB final production | 8mo | 2012-03-30 | 2012-11-08 | 3, 4, 94 |  |  | 16d | 0d | start no earlier than 2011-08-01 |  |  |  |
| 96 | 5.3.1.12 | DCDB tests | 3mo | 2012-11-09 | 2013-01-31 | 95 |  |  | 86d | 0d | start no earlier than 2011-10-21 |  |  |  |
| 97 | 5.3.2 | **1.3.2 Switcher** | 1026d? | 2009-01-01 A | 2012-12-06 |  | 60% | 407.81d? | 126d |  |  | Lead Institute HEI | 8208h | 1755.01h |
| 98 | 5.3.2.1 | Switcher 3 production | 1d? | 2009-01-01 A | 2009-01-01 A |  | 100% |  |  |  |  |  |  |  |
| 99 | 5.3.2.2 | Switcher3 tests | 120d? | 2009-02-01 A | 2009-07-17 A |  | 100% |  |  |  | finish no earlier than 2008-12-23 |  |  |  |
| 100 | 5.3.2.3 | SwitcherB redesign | 6mo | 2009-08-01 A | 2010-02-15 A | 99 | 100% |  |  |  | finish no earlier than 2010-02-15 |  |  |  |
| 101 | 5.3.2.4 | SwitcherB production | 12w | 2010-02-15 A | 2010-05-07 A | 100, 319 | 100% |  |  |  | start no earlier than 2010-02-15 |  |  |  |
| 102 | 5.3.2.5 | bumping studies | 6mo | 2010-05-10 A | 2010-10-22 | 101 | 50% | 3mo | 253d | 274d |  |  |  |  |
| 103 | 5.3.2.6 | SwitcherB tests | 8.55mo | 2010-05-10 A | 2011-01-04 | 101 | 75% | 2.14mo | 409d | 154d | finish no earlier than 2011-01-04 |  |  |  |
| 104 | 5.3.2.7 | SwitcherB design correction | 2mo | 2012-02-03 | 2012-03-29 | 103, 136 |  |  | 126d | 0d | start no earlier than 2011-01-04 |  |  |  |
| 105 | 5.3.2.8 | Switcher final production | 12w | 2012-03-30 | 2012-06-21 | 104, 3 |  |  | 126d | 0d | start no earlier than 2011-08-01 |  |  |  |
| 106 | 5.3.2.9 | switcher thinning | 12w | 2012-06-22 | 2012-09-13 | 105 |  |  | 126d | 0d |  |  |  |  |
| 107 | 5.3.2.10 | switcher tests | 3mo | 2012-09-14 | 2012-12-06 | 106 |  |  | 126d | 40d | start no earlier than 2012-01-13 |  |  |  |

| ID | WBS | Task | Type | Duration | Start | Finish | Predecessors | Complete | Remaining | Total slack | Free slack | Constraint | Deadline | Resources | Work | Actual work |
| --- | --- | --- | --- | --- | --- | --- | --- | --- | --- | --- | --- | --- | --- | --- | --- | --- |
| 108 | 5.3.3 | **1.3.3 DHP** |  | 954d? | 2008-11-11 A | 2012-07-06 |  | 53% | 451.57d? | 235d |  |  |  | Lead Institute BON; Collaborating Institute MPI; Collaborating Institute UBA | 22896h | 2601.32h |
| 109 | 5.3.3.1 | LVDS with preamphasis: design |  | 45d? | 2010-12-01 A | 2011-02-01 A |  | 100% |  |  |  | finish no earlier than 2011-02-01 |  |  |  |  |
| 110 | 5.3.3.2 | LVDS test chip submission |  | 3mo | 2011-05-16 | 2011-08-05 | 109 |  |  | 288d | 0d | start no earlier than 2011-05-16 |  |  |  |  |
| 111 | 5.3.3.3 | DHP Design |  | 49.8w | 2008-11-11 A | 2009-10-23 A |  | 100% |  |  |  | finish no earlier than 2009-10-23 |  |  |  |  |
| 112 | 5.3.3.4 | DHP 01 Test Chip submission |  | 12w | 2010-03-02 A | 2010-05-24 A | 111 | 100% |  |  |  | start no earlier than 2010-03-02 |  |  |  |  |
| 113 | 5.3.3.5 | DHP 01 evaluation |  | 7.65mo | 2010-05-25 A | 2010-12-23 | 112 | 90% | 0.77mo | 41.6d | 35d | start no earlier than 2010-05-24 |  |  |  |  |
| 114 | 5.3.3.6 | FPGA emulator |  | 130d | 2010-06-30 A | 2010-12-28 | 111 | 90% | 13d | 38.6d | 32d | start no earlier than 2010-06-30 |  |  |  |  |
| 115 | 5.3.3.7 | Algorithm evaluation |  | 130d? | 2010-06-30 A | 2010-12-28 | 111 | 10% | 117d? | 0d |  | finish no earlier than 2010-12-28 |  |  |  |  |
| 116 | 5.3.3.8 | DHP 02 Footprint | milestone | 0d | 2011-02-01 | 2011-02-01 | 115 |  |  | -203d | 0d | start no earlier than 2011-02-01 |  |  |  |  |
| 117 | 5.3.3.9 | DHP 02 design |  | 66d? | 2011-02-11 A | 2011-05-13 | 113, 114, 116 | 10% | 59.4d? | 0d |  | finish no earlier than 2011-05-13 |  |  |  |  |
| 118 | 5.3.3.10 | DHP 02 submission |  | 3mo | 2011-05-16 | 2011-08-05 | 117, 3 |  |  | -74d | 0d | start no earlier than 2011-05-16 |  |  |  |  |
| 119 | 5.3.3.11 | DHP 02 evaluation |  | 3mo | 2011-08-08 | 2011-10-28 | 118 |  |  | -74d | 0d | start no earlier than 2011-03-14 |  |  |  |  |
| 120 | 5.3.3.12 | DHP Design correction |  | 3mo | 2011-10-31 | 2012-01-20 | 119 |  |  | 235d | 0d | start no earlier than 2011-09-14 |  |  |  |  |
| 121 | 5.3.3.13 | DHP final production |  | 3mo | 2012-01-23 | 2012-04-13 | 120 |  |  | 235d | 0d | start no earlier than 2011-12-07 |  |  |  |  |
| 122 | 5.3.3.14 | DHP tests |  | 3mo | 2012-04-16 | 2012-07-06 | 121 |  |  | 235d | 149d | start no earlier than 2012-02-29 |  |  |  |  |
| 123 | 5.3.4 | ASIC Prototypes available | milestone | 0d | 2011-11-10 | 2011-11-10 | 101, 93, 119 |  |  | -83d | 0d |  |  |  |  |  |
| 124 | 5.3.5 | All AISCs available | milestone | 0d | 2013-01-31 | 2013-01-31 | 107, 96, 122 |  |  | 86d |  |  |  |  |  |  |
| 125 | 5.3.6 | **Electrical Dummy** |  | 214d | 2011-03-01 | 2011-12-23 | 133, 132 |  |  | 375d | 189d |  |  |  |  |  |
| 126 | 5.3.6.1 | Processing |  | 3mo | 2011-03-01 | 2011-05-23 |  |  |  | 429d | 54d | start no earlier than 2011-03-01 |  |  |  |  |
| 127 | 5.3.6.2 | Assembly |  | 2mo | 2011-08-08 | 2011-09-30 | 126, 103, 118, 89 |  |  | 375d | 0d |  |  |  |  |  |
| 128 | 5.3.6.3 | Test |  | 3mo | 2011-10-03 | 2011-12-23 | 127 |  |  | 375d |  |  |  |  |  |  |
| 129 | 5.4 | **1.4 Module** |  | 961d? | 2009-05-26 A | 2013-01-29 |  | 49% | 485.64d? | -21d | 0d |  | 2012-12-31 |  | 46128h | 19249.1h |
| 130 | 5.4.1 | **1.4.1 Sensor ladder R&D** |  | 961d? | 2009-05-26 A | 2013-01-29 |  | 49% | 485.64d? | -21d | 0d |  |  | Lead Institute MPI; Collaborating Institute HEI; Collaborating Institute BON; Collaborating Institute IFV; Collaborationg Institute CNM; Collaborating Institute IFB | 46128h | 19249.1h |
| 131 | 5.4.1.1 | Dummy Sensor (mechanical) |  | 10.5mo | 2009-05-26 A | 2010-03-15 A | 23 | 100% |  |  |  | finish no earlier than 2010-03-15 |  |  |  |  |
| 132 | 5.4.1.2 | Dummy Sensors (electrical) |  | 3mo | 2010-01-01 | 2010-03-25 | 23 |  |  | 671d | 242d | start no earlier than 2010-01-01 |  |  |  |  |
| 133 | 5.4.1.3 | Dummy Modules (mechanical) |  | 2mo | 2010-03-26 A | 2010-05-20 A | 132, 131 | 100% |  |  |  | start no earlier than 2009-06-22 |  |  |  |  |
| 134 | 5.4.1.4 | Module to ladder joint |  | 6mo | 2010-03-16 A | 2010-08-30 A | 131 | 100% |  |  |  |  |  |  |  |  |
| 135 | 5.4.1.5 | Prototyp Module |  | 3mo | 2011-11-11 | 2012-02-02 | 102, 134, 37, 123 |  |  | -21d | 0d | start no earlier than 2008-01-01 |  |  |  |  |
| 136 | 5.4.1.6 | Prototype available | milestone | 0d | 2012-02-02 | 2012-02-02 | 135 |  |  | 126d | 0d | start no earlier than 2010-07-01 |  |  |  |  |
| 137 | 5.4.1.7 | Production Preparation |  | 258d? | 2012-02-03 | 2013-01-29 | 135 |  |  | -21d | 0d | start no earlier than 2011-03-01 |  |  |  |  |

| ID | WBS | Task | Duration | Start | Finish | Predecessors | Total slack | Free slack | Constraint |
| --- | --- | --- | --- | --- | --- | --- | --- | --- | --- |
| 138 | 5.5 | **Ladder Assembly** | 193d | 2013-06-24 | 2014-03-19 |  | -319d | 0d |  |
| 139 | 5.5.1 | **Sensor Assembly (Flip Chip)** | 183d | 2013-06-24 | 2014-03-05 | 81 | -319d | 0d |  |
| 140 | 5.5.1.1 | modules (2) for i1 | 2w | 2013-06-24 | 2013-07-05 | 81, 73 | -319d | 0d | start no earlier than 2013-06-24 |
| 141 | 5.5.1.2 | modules (2) fos i2 | 2w | 2013-07-08 | 2013-07-19 | 140 | -319d | 0d | start no earlier than 2012-02-16 |
| 142 | 5.5.1.3 | modules (2) for i3 | 2w | 2013-07-22 | 2013-08-02 | 141 | -319d | 0d |  |
| 143 | 5.5.1.4 | modules (2) for i4 | 2w | 2013-08-05 | 2013-08-16 | 142 | -319d | 0d |  |
| 144 | 5.5.1.5 | moduels (2) for i5 | 2w | 2013-08-19 | 2013-08-30 | 143 | -319d | 0d |  |
| 145 | 5.5.1.6 | modules (2) for i6 | 2w | 2013-09-02 | 2013-09-13 | 144 | -319d | 0d |  |
| 146 | 5.5.1.7 | modules (2) for i7 | 2w | 2013-09-16 | 2013-09-27 | 145 | -319d | 0d |  |
| 147 | 5.5.1.8 | modules (2) for i8 | 2w | 2013-09-30 | 2013-10-11 | 146 | -319d | 0d |  |
| 148 | 5.5.1.9 | modules (2) for ir1 | 1w | 2013-10-14 | 2013-10-18 | 147 | -319d | 0d |  |
| 149 | 5.5.1.10 | modules (2) for ir2 | 1w | 2013-10-21 | 2013-10-25 | 148 | -319d | 0d |  |
| 150 | 5.5.1.11 | modules (2) for ir3 | 1w | 2013-10-28 | 2013-11-01 | 149 | -319d | 0d |  |
| 151 | 5.5.1.12 | modules (2) for o1 | 1w | 2013-11-28 | 2013-12-04 | 150, 82 | -337d | 0d |  |
| 152 | 5.5.1.13 | modules (2) for o2 | 1w | 2013-12-05 | 2013-12-11 | 151 | -337d | 0d |  |
| 153 | 5.5.1.14 | modules (2) for o3 | 1w | 2013-12-12 | 2013-12-18 | 152 | -337d | 0d |  |
| 154 | 5.5.1.15 | modules (2) for o4 | 1w | 2013-12-19 | 2013-12-25 | 153 | -337d | 0d |  |
| 155 | 5.5.1.16 | modules (2) for o5 | 1w | 2013-12-26 | 2014-01-01 | 154 | -337d | 0d |  |
| 156 | 5.5.1.17 | modules (2) for o6 | 1w | 2014-01-02 | 2014-01-08 | 155 | -337d | 0d |  |
| 157 | 5.5.1.18 | modules (2) for o7 | 1w | 2014-01-09 | 2014-01-15 | 156 | -337d | 0d |  |
| 158 | 5.5.1.19 | modules (2) for o8 | 1w | 2014-01-16 | 2014-01-22 | 157 | -337d | 0d |  |
| 159 | 5.5.1.20 | modules (2) for o9 | 1w | 2014-01-23 | 2014-01-29 | 158 | -337d | 0d |  |
| 160 | 5.5.1.21 | modules (2) for o10 | 1w | 2014-01-30 | 2014-02-05 | 159 | -337d | 0d |  |
| 161 | 5.5.1.22 | modules (2) for o11 | 1w | 2014-02-06 | 2014-02-12 | 160 | -337d | 0d |  |
| 162 | 5.5.1.23 | modules (2) for o12 | 1w | 2014-02-13 | 2014-02-19 | 161 | -337d | 0d |  |
| 163 | 5.5.1.24 | modules (2) for or1 | 1w | 2014-02-20 | 2014-02-26 | 162 | -208d | 0d |  |
| 164 | 5.5.1.25 | modules (2) for or2 | 1w | 2014-02-27 | 2014-03-05 | 163 | -208d | 0d |  |

| ID | WBS | Task | Duration | Start | Finish | Predecessors | Total slack | Free slack |
| --- | --- | --- | --- | --- | --- | --- | --- | --- |
| 165 | 5.5.2 | **Module Tests** | 176d | 2013-07-08 | 2014-03-10 |  | -208d | 0d |
| 166 | 5.5.2.1 | module I1 test | 3d | 2013-07-08 | 2013-07-10 | 140 | -35d | 0d |
| 167 | 5.5.2.2 | module I2 test | 3d | 2013-07-22 | 2013-07-24 | 141 | -45d | 0d |
| 168 | 5.5.2.3 | module I3 test | 3d | 2013-08-05 | 2013-08-07 | 142 | -55d | 0d |
| 169 | 5.5.2.4 | module I4 test | 3d | 2013-08-19 | 2013-08-21 | 143 | -65d | 0d |
| 170 | 5.5.2.5 | module I5 test | 3d | 2013-09-02 | 2013-09-04 | 144 | -75d | 0d |
| 171 | 5.5.2.6 | module I6 test | 3d | 2013-09-16 | 2013-09-18 | 145 | -85d | 0d |
| 172 | 5.5.2.7 | module I7 test | 3d | 2013-09-30 | 2013-10-02 | 146 | -95d | 0d |
| 173 | 5.5.2.8 | module I8 test | 3d | 2013-10-14 | 2013-10-16 | 147 | -254d | 0d |
| 174 | 5.5.2.9 | module ir1 test | 3d | 2013-10-21 | 2013-10-23 | 148 | -110d | 0d |
| 175 | 5.5.2.10 | module ir2 test | 3d | 2013-10-28 | 2013-10-30 | 149 | -115d | 0d |
| 176 | 5.5.2.11 | module ir3 test | 3d | 2013-11-04 | 2013-11-06 | 150 | -120d | 0d |
| 177 | 5.5.2.12 | module O1 test | 3d | 2013-12-05 | 2013-12-09 | 151 | -143d | 0d |
| 178 | 5.5.2.13 | module O2 test | 3d | 2013-12-12 | 2013-12-16 | 152 | -148d | 0d |
| 179 | 5.5.2.14 | module O3 test | 3d | 2013-12-19 | 2013-12-23 | 153 | -153d | 0d |
| 180 | 5.5.2.15 | module O4 test | 3d | 2013-12-26 | 2013-12-30 | 154 | -158d | 0d |
| 181 | 5.5.2.16 | module O5 test | 3d | 2014-01-02 | 2014-01-06 | 155 | -163d | 0d |
| 182 | 5.5.2.17 | module O6 test | 3d | 2014-01-09 | 2014-01-13 | 156 | -168d | 0d |
| 183 | 5.5.2.18 | module O7 test | 3d | 2014-01-16 | 2014-01-20 | 157 | -173d | 0d |
| 184 | 5.5.2.19 | module O8 test | 3d | 2014-01-23 | 2014-01-27 | 158 | -178d | 0d |
| 185 | 5.5.2.20 | module O9 test | 3d | 2014-01-30 | 2014-02-03 | 159 | -183d | 0d |
| 186 | 5.5.2.21 | module O10 test | 3d | 2014-02-06 | 2014-02-10 | 160 | -188d | 0d |
| 187 | 5.5.2.22 | module O11 test | 3d | 2014-02-13 | 2014-02-17 | 161 | -193d | 0d |
| 188 | 5.5.2.23 | module O12 test | 3d | 2014-02-20 | 2014-02-24 | 162 | -337d | 0d |
| 189 | 5.5.2.24 | module or1 test | 3d | 2014-02-27 | 2014-03-03 | 163 | -203d | 0d |
| 190 | 5.5.2.25 | module or2 test | 3d | 2014-03-06 | 2014-03-10 | 164 | -208d | 0d |

| ID | WBS | Task | Duration | Start | Finish | Predecessors | Total slack | Free slack |
| --- | --- | --- | --- | --- | --- | --- | --- | --- |
| 191 | 5.5.3 | **Kapton assembly (& test)** | 175d | 2013-07-11 | 2014-03-12 |  | -208d | 0d |
| 192 | 5.5.3.1 | module i1 | 2d | 2013-07-11 | 2013-07-12 | 166, 248 | -35d | 0d |
| 193 | 5.5.3.2 | module i2 | 2d | 2013-07-25 | 2013-07-26 | 167 | -45d | 0d |
| 194 | 5.5.3.3 | module i3 | 2d | 2013-08-08 | 2013-08-09 | 168 | -55d | 0d |
| 195 | 5.5.3.4 | module i4 | 2d | 2013-08-22 | 2013-08-23 | 169 | -65d | 0d |
| 196 | 5.5.3.5 | module i5 | 2d | 2013-09-05 | 2013-09-06 | 170 | -75d | 0d |
| 197 | 5.5.3.6 | module i6 | 2d | 2013-09-19 | 2013-09-20 | 171 | -85d | 0d |
| 198 | 5.5.3.7 | module i7 | 2d | 2013-10-03 | 2013-10-04 | 172 | -95d | 0d |
| 199 | 5.5.3.8 | module i8 | 2d | 2013-10-17 | 2013-10-18 | 173 | -254d | 0d |
| 200 | 5.5.3.9 | module ir1 | 2d | 2013-10-24 | 2013-10-25 | 174 | -110d | 0d |
| 201 | 5.5.3.10 | module ir1 | 2d | 2013-11-07 | 2013-11-08 | 175, 176 | -120d | 0d |
| 202 | 5.5.3.11 | module o1 | 2d | 2013-12-10 | 2013-12-11 | 177 | -143d | 0d |
| 203 | 5.5.3.12 | module o2 | 2d | 2013-12-17 | 2013-12-18 | 178 | -148d | 0d |
| 204 | 5.5.3.13 | module o3 | 2d | 2013-12-24 | 2013-12-25 | 179 | -153d | 0d |
| 205 | 5.5.3.14 | module o4 | 2d | 2013-12-31 | 2014-01-01 | 180 | -158d | 0d |
| 206 | 5.5.3.15 | module o5 | 2d | 2014-01-07 | 2014-01-08 | 181 | -163d | 0d |
| 207 | 5.5.3.16 | module o6 | 2d | 2014-01-14 | 2014-01-15 | 182 | -168d | 0d |
| 208 | 5.5.3.17 | module o7 | 2d | 2014-01-21 | 2014-01-22 | 183 | -173d | 0d |
| 209 | 5.5.3.18 | module o8 | 2d | 2014-01-28 | 2014-01-29 | 184 | -178d | 0d |
| 210 | 5.5.3.19 | module o9 | 2d | 2014-02-04 | 2014-02-05 | 185 | -183d | 0d |
| 211 | 5.5.3.20 | module o10 | 2d | 2014-02-11 | 2014-02-12 | 186 | -188d | 0d |
| 212 | 5.5.3.21 | module o11 | 2d | 2014-02-18 | 2014-02-19 | 187 | -193d | 0d |
| 213 | 5.5.3.22 | module o12 | 2d | 2014-02-25 | 2014-02-26 | 188 | -337d | 0d |
| 214 | 5.5.3.23 | module or1 | 2d | 2014-03-04 | 2014-03-05 | 189 | -203d | 0d |
| 215 | 5.5.3.24 | module or2 | 2d | 2014-03-11 | 2014-03-12 | 190 | -208d | 0d |

| ID | WBS | Task | Duration | Start | Finish | Predecessors | Total slack | Free slack |
| --- | --- | --- | --- | --- | --- | --- | --- | --- |
| 216 | 5.5.4 | **Ladder glueing & Test** | 178d | 2013-07-15 | 2014-03-19 |  | -208d | 0d |
| 217 | 5.5.4.1 | ladder i1 | 1w | 2013-07-15 | 2013-07-19 | 192 | -35d | 0d |
| 218 | 5.5.4.2 | ladder i2 | 1w | 2013-07-29 | 2013-08-02 | 193 | -45d | 0d |
| 219 | 5.5.4.3 | oadder i3 | 1w | 2013-08-12 | 2013-08-16 | 194 | -55d | 0d |
| 220 | 5.5.4.4 | ladder i4 | 1w | 2013-08-26 | 2013-08-30 | 195 | -65d | 0d |
| 221 | 5.5.4.5 | ladder i5 | 1w | 2013-09-09 | 2013-09-13 | 196 | -75d | 0d |
| 222 | 5.5.4.6 | ladder i6 | 1w | 2013-09-23 | 2013-09-27 | 197 | -85d | 0d |
| 223 | 5.5.4.7 | ladder i7 | 1w | 2013-10-07 | 2013-10-11 | 198 | -95d | 0d |
| 224 | 5.5.4.8 | ladder i8 | 1w | 2013-10-21 | 2013-10-25 | 199 | -254d | 0d |
| 225 | 5.5.4.9 | ladder ir1 | 1w | 2013-10-28 | 2013-11-01 | 200 | -110d | 0d |
| 226 | 5.5.4.10 | ladder ir2 | 1w | 2013-11-11 | 2013-11-15 | 201 | -120d | 0d |
| 227 | 5.5.4.11 | ladder o1 | 1w | 2013-12-12 | 2013-12-18 | 202 | -143d | 0d |
| 228 | 5.5.4.12 | ladder o2 | 1w | 2013-12-19 | 2013-12-25 | 203 | -148d | 0d |
| 229 | 5.5.4.13 | ladder o3 | 1w | 2013-12-26 | 2014-01-01 | 204 | -153d | 0d |
| 230 | 5.5.4.14 | ladder o4 | 1w | 2014-01-02 | 2014-01-08 | 205 | -158d | 0d |
| 231 | 5.5.4.15 | ladder o5 | 1w | 2014-01-09 | 2014-01-15 | 206 | -163d | 0d |
| 232 | 5.5.4.16 | ladder o6 | 1w | 2014-01-16 | 2014-01-22 | 207 | -168d | 0d |
| 233 | 5.5.4.17 | ladder o7 | 1w | 2014-01-23 | 2014-01-29 | 208 | -173d | 0d |
| 234 | 5.5.4.18 | ladder o8 | 1w | 2014-01-30 | 2014-02-05 | 209 | -178d | 0d |
| 235 | 5.5.4.19 | ladder o9 | 1w | 2014-02-06 | 2014-02-12 | 210 | -183d | 0d |
| 236 | 5.5.4.20 | ladder o10 | 1w | 2014-02-13 | 2014-02-19 | 211 | -188d | 0d |
| 237 | 5.5.4.21 | ladder o11 | 1w | 2014-02-20 | 2014-02-26 | 212 | -193d | 0d |
| 238 | 5.5.4.22 | ladder o12 | 1w | 2014-02-27 | 2014-03-05 | 213 | -337d | 0d |
| 239 | 5.5.4.23 | ladder or1 | 1w | 2014-03-06 | 2014-03-12 | 214 | -203d | 0d |
| 240 | 5.5.4.24 | ladder or2 | 1w | 2014-03-13 | 2014-03-19 | 215 | -208d | 0d |

| ID | WBS | Task | Duration | Start | Finish | Predecessors | Complete | Remaining | Total slack | Free slack | Constraint | Resources | Work | Actual work |
| --- | --- | --- | --- | --- | --- | --- | --- | --- | --- | --- | --- | --- | --- | --- |
| 241 | 5.6 | **1.4.2 Kapton link: Module-DHH** | 705d | 2010-01-01 A | 2012-09-13 |  | 3% | 683.85d | 179d |  |  | Lead Institute KEK; Collaborating Institute VIE; Collaborating Institute BON | 16920h | 507.6h |
| 242 | 5.6.1 | Kapton link design studies | 3mo | 2010-01-01 A | 2010-03-25 |  | 20% | 2.4mo | 641d | 242d | start no earlier than 2010-01-01 |  |  |  |
| 243 | 5.6.2 | Test sample production | 2mo | 2011-02-01 | 2011-03-28 |  |  |  | 50d |  | start no earlier than 2011-02-01 |  |  |  |
| 244 | 5.6.3 | Kapton link design | 90d | 2011-02-01 | 2011-06-06 | 111, 2 |  |  | 0d |  | start no earlier than 2011-02-01 |  |  |  |
| 245 | 5.6.4 | Kapton Link prototype production | 30d | 2011-06-07 | 2011-07-18 | 244, 243 |  |  | 0d |  | start no earlier than 2010-06-22 |  |  |  |
| 246 | 5.6.5 | Signal integrity tests | 60d | 2011-08-08 | 2011-10-28 | 245, 110 |  |  | 288d | 109d |  |  |  |  |
| 247 | 5.6.6 | Final Production | 100d | 2012-03-30 | 2012-08-16 | 113, 4, 246 |  |  | 179d | 0d |  |  |  |  |
| 248 | 5.6.7 | Tests | 4w | 2012-08-17 | 2012-09-13 | 247 |  |  | 179d |  |  |  |  |  |
| 249 | 5.7 | **1.4.2.1 Patch Panel** | 615d? | 2010-01-01 A | 2012-05-10 |  | 49% | 313d? | 276d |  |  |  |  |  |
| 250 | 5.7.1 | Patch panel design studies | 302d | 2010-01-01 A | 2011-02-28 |  | 80% | 60.4d | 399d | 0d | start no earlier than 2010-01-01 |  |  |  |
| 251 | 5.7.2 | Patch Panel Design | 90d | 2011-03-01 | 2011-07-04 | 242, 250 |  |  | 399d | 123d | start no earlier than 2011-01-03 |  |  |  |
| 252 | 5.7.3 | Patch pannel production | 100d? | 2011-12-23 | 2012-05-10 | 251 |  |  | 276d |  | start no earlier than 2011-12-23 |  |  |  |
| 253 | 5.8 | **1.4.3.DHH** | 818d? | 2010-03-23 A | 2013-05-09 |  | 13% | 708.58d? | 16d |  |  |  |  |  |
| 254 | 5.8.1 | DHH design | 138d? | 2010-03-23 A | 2010-09-30 |  | 60% | 55.2d? | 117d | 40d | start no earlier than 2010-03-23 |  |  |  |
| 255 | 5.8.2 | DHH prototype production | 90d | 2010-11-26 | 2011-03-31 | 254, 2 |  |  | 77d | 0d | finish no earlier than 2011-03-31 |  |  |  |
| 256 | 5.8.3 | Tests | 218d? | 2011-04-01 | 2012-01-31 | 255 |  |  | 175d | 0d | start no earlier than 2011-03-31 |  |  |  |
| 257 | 5.8.4 | DHH final design | 43d? | 2012-02-01 | 2012-03-30 | 256 |  |  | 175d | 159d | start no earlier than 2012-01-31 |  |  |  |
| 258 | 5.8.5 | Final production | 130d | 2012-11-09 | 2013-05-09 | 113, 136, 95, 4, 257 |  |  | 16d |  | finish no earlier than 2012-09-28 |  |  |  |
| 259 | 5.9 | **1.5 Mechanical Support** | 1000d? | 2009-05-01 A | 2013-02-28 |  | 42% | 582.32d? | -83d | 0d |  | Lead Institute KAR; Collaborating Institute VIE; Collaborating Institute KRA; Collaborating Institute IFV; Collaborating Institute USC; Collaborating Institute IFB | 48000h | 4045.75h |
| 260 | 5.9.1 | Design | 262d? | 2009-05-01 A | 2010-05-03 |  | 90% | 26.2d? | 0d |  | finish no earlier than 2010-05-03 |  |  |  |
| 261 | 5.9.2 | Mechanical Model | 6mo | 2010-08-31 A | 2011-02-14 | 133, 134, 260 | 20% | 4.8mo | 210d |  | start no earlier than 2009-07-31 |  |  |  |
| 262 | 5.9.3 | Mechanics | 12mo | 2012-03-30 | 2013-02-28 | 261, 264, 4 |  |  | -83d | 0d | start no earlier than 2012-01-04 |  |  |  |
| 263 | 5.10 | **1.6 Thermal Issues** | 631d? | 2009-03-31 A | 2011-08-30 |  | 72% | 178.5d? | 69d |  |  |  |  |  |
| 264 | 5.10.1 | FEA Simulation (thermal) | 393d? | 2009-03-31 A | 2010-09-30 A |  | 100% |  |  |  | start no earlier than 2009-03-31 |  |  |  |
| 265 | 5.10.2 | Thermal Mockup | 11.9mo | 2010-10-01 A | 2011-08-30 | 264 | 25% | 8.93mo | 69d |  | start no earlier than 2010-09-01 |  |  |  |

| ID | WBS | Task | Type | Duration | Start | Finish | Predecessors | Complete | Remaining | Total slack | Free slack | Constraint | Resources | Work |
| --- | --- | --- | --- | --- | --- | --- | --- | --- | --- | --- | --- | --- | --- | --- |
| 266 | 5.11 | **1.7 System** |  | 1172d? | 2008-07-09 A | 2013-01-03 |  | 6% | 1099.85d? | 106d |  |  |  | 79384h |
| 267 | 5.11.1 | **1.7.1 DAQ board** |  | 1169d? | 2008-07-09 | 2012-12-31 |  |  |  | 109d |  |  | Lead Institute KRA; Collaborating Institute MPI; Collaborating Institute KEK; Collaborating Institute USC; Collaborating Institute URL; Collaborating Institute GOE; Collaborating Institute HAW | 65464h |
| 268 | 5.11.1.1 | DAQ |  | 1169d? | 2008-07-09 | 2012-12-31 |  |  |  | 109d |  | finish no earlier than 2012-12-31 |  |  |
| 269 | 5.11.2 | **1.7.2 Power Supplies** |  | 580d | 2010-10-01 | 2012-12-20 |  |  |  | -33d | 0d |  | Lead Institute KRA; Collaborating Institute PRA; Collaborating Institute KEK | 13920h |
| 270 | 5.11.2.1 | Definition |  | 150d | 2010-10-01 | 2011-04-28 |  |  |  | -33d | 0d | start no earlier than 2010-10-01 |  |  |
| 271 | 5.11.2.2 | Grounding analysis |  | 150d | 2010-10-01 | 2011-04-28 |  |  |  | 546d |  | start no earlier than 2010-10-01 |  |  |
| 272 | 5.11.2.3 | **Analog design** |  | 210d | 2010-10-01 | 2011-07-21 |  |  |  | 57d |  |  |  |  |
| 273 | 5.11.2.3.1 | **Analyse regulation over long ditance** |  | 90d | 2010-10-01 | 2011-02-03 |  |  |  | 406d |  |  |  |  |
| 274 | 5.11.2.3.1.1 | Test circuits |  | 90d | 2010-10-01 | 2011-02-03 |  |  |  | 406d | 60d | start no earlier than 2010-10-01 |  |  |
| 275 | 5.11.2.3.1.2 | Simulation |  | 90d | 2010-10-01 | 2011-02-03 |  |  |  | 406d | 60d | start no earlier than 2010-10-01 |  |  |
| 276 | 5.11.2.3.2 | decision: regulator vers bulk | milestone | 0d | 2011-04-29 | 2011-04-29 | 270, 274, 275 |  |  | 346d | 240d | start no earlier than 2011-04-29 |  |  |
| 277 | 5.11.2.3.3 | Simulate/Test hardware current limits |  | 50d | 2010-10-01 | 2010-12-09 |  |  |  | 67d |  | start no earlier than 2010-10-01 |  |  |
| 278 | 5.11.2.3.4 | Overvoltage protection |  | 60d | 2010-10-01 | 2010-12-23 |  |  |  | 57d |  | start no earlier than 2010-10-01 |  |  |
| 279 | 5.11.2.3.5 | Design cables |  | 60d | 2010-10-01 | 2010-12-23 |  |  |  | 57d |  | start no earlier than 2010-10-01 |  |  |
| 280 | 5.11.2.3.6 | Layout of test circuits |  | 60d | 2011-04-29 | 2011-07-21 | 270, 277, 278, 279 |  |  | -33d | 0d |  |  |  |
| 281 | 5.11.2.3.7 | Demonstration of PS analogue circuit | milestone | 0d | 2011-07-21 | 2011-07-21 | 280 |  |  | -33d | 0d |  |  |  |
| 282 | 5.11.2.4 | **Digital design** |  | 135d | 2010-10-01 | 2011-04-07 |  |  |  | 42d |  |  |  |  |
| 283 | 5.11.2.4.1 | Evaluation microcontroller/FPGA |  | 25d | 2010-10-01 | 2010-11-04 |  |  |  | 42d | 0d | start no earlier than 2010-10-01 |  |  |
| 284 | 5.11.2.4.2 | Investigations with testboards |  | 60d | 2010-11-05 | 2011-01-27 | 283 |  |  | 42d | 0d |  |  |  |
| 285 | 5.11.2.4.3 | Decision: slow control interface | milestone | 0d | 2011-01-27 | 2011-01-27 | 284 |  |  | 42d | 0d |  |  |  |
| 286 | 5.11.2.4.4 | Layout and production |  | 50d | 2011-01-28 | 2011-04-07 | 285 |  |  | 42d | 0d |  |  |  |
| 287 | 5.11.2.4.5 | Demonstration | milestone | 0d | 2011-04-07 | 2011-04-07 | 286 |  |  | 42d |  |  |  |  |
| 288 | 5.11.2.5 | **prototyping** |  | 220d | 2011-07-22 | 2012-05-24 | 281, 287 |  |  | -33d | 0d |  |  |  |
| 289 | 5.11.2.5.1 | Software development |  | 40d | 2011-07-22 | 2011-09-15 |  |  |  | -33d | 0d | start no earlier than 2011-04-07 |  |  |
| 290 | 5.11.2.5.2 | Design and layout |  | 60d | 2011-09-16 | 2011-12-08 | 289 |  |  | -33d | 0d |  |  |  |
| 291 | 5.11.2.5.3 | Production |  | 30d | 2011-12-09 | 2012-01-19 | 290 |  |  | -33d | 0d |  |  |  |
| 292 | 5.11.2.5.4 | Lab Test |  | 90d | 2012-01-20 | 2012-05-24 | 291 |  |  | -33d | 0d |  |  |  |
| 293 | 5.11.2.5.5 | Demonstration of multi module operation | milestone | 0d | 2012-05-24 | 2012-05-24 | 292 |  |  | -33d | 0d |  |  |  |

| ID | WBS | Task | Type | Duration | Start | Finish | Predecessors | Complete | Remaining | Total slack | Free slack | Constraint |
| --- | --- | --- | --- | --- | --- | --- | --- | --- | --- | --- | --- | --- |
| 294 | 5.11.2.6 | **Final Production** |  | 130d | 2012-05-25 | 2012-11-22 | 293 |  |  | -33d | 0d |  |
| 295 | 5.11.2.6.1 | Mass production |  | 60d | 2012-05-25 | 2012-08-16 |  |  |  | -33d | 0d |  |
| 296 | 5.11.2.6.2 | Testing |  | 70d | 2012-08-17 | 2012-11-22 | 295 |  |  | -33d | 0d |  |
| 297 | 5.11.2.7 | **Installation** |  | 20d | 2012-11-23 | 2012-12-20 | 294 |  |  | -33d | 0d |  |
| 298 | 5.11.2.7.1 | Shipping |  | 10d | 2012-11-23 | 2012-12-06 |  |  |  | -33d | 0d |  |
| 299 | 5.11.2.7.2 | Installation & Final tests |  | 10d | 2012-12-07 | 2012-12-20 | 298 |  |  | -33d | 0d |  |
| 300 | 5.11.3 | **1.7.3 Cooling plant** |  | 858d? | 2009-06-02 A | 2012-09-13 |  | 47% | 450.59d? | 77d |  |  |
| 301 | 5.11.3.1 | Cooling plant studies |  | 217d? | 2009-06-02 A | 2010-03-31 A |  | 100% |  |  |  | finish no earlier than 2010-03-31 |
| 302 | 5.11.3.2 | Cooling descision (medium) | milestone | 0d | 2010-03-31 A | 2010-03-31 A | 301 | 100% |  |  |  | start no earlier than 2010-03-31 |
| 303 | 5.11.3.3 | Cooling plant design |  | 6mo | 2011-03-01 | 2011-08-15 | 302 |  |  | 80d | 163d | start no earlier than 2011-03-01 |
| 304 | 5.11.3.4 | Cooling plant production |  | 6mo | 2012-03-30 | 2012-09-13 | 303, 4 |  |  | 77d | 0d | start no earlier than 2010-10-01 |
| 305 | 5.11.4 | **Services** |  | 828d? | 2009-11-03 | 2013-01-03 |  |  |  | 106d |  |  |
| 306 | 5.11.4.1 | Volume definition and request |  | 84d? | 2009-11-03 | 2010-02-26 |  |  |  | 850d |  | finish no earlier than 2010-02-26 |
| 307 | 5.11.4.2 | Cooling pipes |  | 200d | 2012-03-30 | 2013-01-03 | 4 |  |  | 106d |  |  |
| 308 | 5.11.4.3 | Power cables |  | 200d | 2012-03-30 | 2013-01-03 | 4, 276 |  |  | 106d |  |  |
| 309 | 5.11.4.4 | optical fibers |  | 200d | 2012-03-30 | 2013-01-03 | 4 |  |  | 106d |  |  |
| 310 | 6 | **1.9 Cables** |  | 720d | 2011-02-01 | 2013-11-04 |  |  |  | 236d |  |  |
| 311 | 6.1 | Cables patch panel - DHH |  | 36mo | 2011-02-01 | 2013-11-04 |  |  |  | 236d |  | start no earlier than 2011-02-01 |
| 312 | 6.2 | cables DHH -PS |  | 36mo | 2011-02-01 | 2013-11-04 |  |  |  | 236d |  | start no earlier than 2011-02-01 |
| 313 | 6.3 | optical fibres |  | 36mo | 2011-02-01 | 2013-11-04 |  |  |  | 236d |  | start no earlier than 2011-02-01 |
| 314 | 7 | **2.0 Test Systems** |  | 1379d? | 2008-07-01 A | 2013-10-11 |  | 25% | 1035.2d? | 252d |  |  |
| 315 | 7.1 | Module thermal tests (with dummy) |  | 129d? | 2012-09-14 | 2013-03-13 | 264, 304, 125 |  |  | 252d | 0d |  |
| 316 | 7.2 | System thermal test (with dummy( |  | 152d | 2013-03-14 | 2013-10-11 | 315, 261 |  |  | 252d | 0d | start no earlier than 2009-11-01 |
| 317 | 7.3 | Cooling demonstrated | milestone | 0d? | 2013-10-11 | 2013-10-11 | 316 |  |  | 252d |  | finish no earlier than 2010-05-01 |
| 318 | 7.4 | small system evaluation |  | 3mo | 2009-10-19 A | 2010-01-11 A | 86, 99 | 100% |  |  |  | finish no earlier than 2010-01-11 |
| 319 | 7.5 | system speed demo | milestone | 0d | 2010-01-11 A | 2010-01-11 A | 318 | 100% |  |  |  | start no earlier than 2010-01-11 |
| 320 | 7.6 | system evaluation (large matrices) |  | 100d | 2011-11-11 | 2012-03-29 | 318, 123, 255, 245 |  |  | -83d | 0d | finish no earlier than 2010-12-23 |
| 321 | 7.7 | design and fabricate test boards for PXD6,1 |  | 322d? | 2009-10-01 | 2010-12-24 |  |  |  | 276d | 0d | finish no earlier than 2010-12-24 |
| 322 | 7.8 | Testbeam |  | 359d? | 2009-07-23 A | 2012-08-22 |  | 15% | 305.15d? | 549d |  | start no earlier than 2009-07-01 |
| 323 | 7.9 | Irradiations |  | 1198d? | 2008-07-01 A | 2013-01-31 |  | 35% | 773.5d? | 433d |  | start no earlier than 2008-07-01 |
| 324 | 7.10 | irradiation tests of thin oxides & evaluation |  | 4mo | 2009-11-16 A | 2010-03-05 |  | 75% | 1mo | 1192d |  | start no earlier than 2009-11-16 |

| ID | WBS | Task | Type | Duration | Start | Finish | Predecessors | Total slack | Free slack | Constraint | Deadline |
| --- | --- | --- | --- | --- | --- | --- | --- | --- | --- | --- | --- |
| 325 | 8 | **Intergration/Installation** |  | 237d | 2013-11-04 | 2014-10-01 |  | -347d | 0d |  |  |
| 326 | 8.1 | mounting and test of 1st layer |  | 2w | 2013-11-04 | 2013-11-15 | 262, 299, 224 | -259d | 0d | finish no earlier than 2013-11-15 |  |
| 327 | 8.2 | mounting and test of 2nd layer |  | 2w | 2014-03-06 | 2014-03-19 | 326, 238 | -337d | 0d | start no earlier than 2014-02-07 |  |
| 328 | 8.3 | system test |  | 1mo | 2014-03-20 | 2014-04-16 | 327 | -337d | 0d | start no earlier than 2014-02-21 |  |
| 329 | 8.4 | BP/PXD/SVD completion |  | 5.45mo | 2014-05-01 | 2014-09-30 | 304, 328 | -347d | 0d | start no earlier than 2014-05-01 |  |
| 330 | 8.5 | System ready for Belle II | milestone | 0d | 2014-10-01 | 2014-10-01 | 329 | -347d | 0d | start no earlier than 2014-10-01 | 2013-05-31 |
